# ICBN Admin Phase II

Schedule from MS Project, 2003-11-14 to 2004-03-01, status date 2003-11-21, 3 hours a day, costs in $, A marks actual dates.
IC Broker, Inc.

## Calendars

- Jason WP Work Week: Mon-Fri 08:00-12:00, 13:00-17:00; Sat-Sun off. Exceptions (off unless hours are given): 2003-11-17 to 2003-11-19, 2003-11-22 19:00-23:59, 2003-11-23 14:00-17:00, 20:00-22:00, 2003-11-24 to 2003-11-26, 2003-11-27 22:00-23:59, 2003-11-28 to 2003-11-29 00:00-03:00, 10:00-12:00, 14:00-16:00, 22:00-23:59, 2003-11-30 14:00-16:00, 20:00-22:00, 2003-12-01 to 2003-12-03, 2003-12-04 21:00-23:59, 2003-12-05 09:00-12:00, 13:00-18:00, 2003-12-08 to 2003-12-11, 2003-12-12 09:00-12:00, 13:00-17:00, 2003-12-15 to 2003-12-17, 2003-12-18 09:00-23:59, 2003-12-19 09:00-12:00, 13:00-18:00, 2003-12-22 to 2003-12-26, 2003-12-29 to 2004-01-01, 2004-01-02 to 2004-01-03 10:00-13:00, 15:00-18:00, 21:00-23:59, 2004-01-05 to 2004-01-07, 2004-01-08 20:00-23:00, 2004-01-09 09:00-12:00, 13:00-18:00, 2004-01-10 08:00-12:00, 13:00-17:00, 2004-01-12 to 2004-01-14, 2004-01-15 00:00-12:00, 2004-01-16 09:00-12:00, 13:00-18:00, 2004-01-17 08:00-12:00, 13:00-17:00, 2004-01-19 to 2004-01-21, 2004-01-22 09:00-12:00, 2004-01-23 09:00-12:00, 13:00-18:00, 2004-01-24 08:00-12:00, 13:00-17:00, 2004-01-26 to 2004-01-28, 2004-01-29 09:00-12:00, 2004-01-30 09:00-12:00, 13:00-18:00, 2004-01-31 08:00-12:00, 13:00-17:00, 2004-02-05 09:00-12:00, 2004-02-06 to 2004-02-07 08:00-12:00, 13:00-17:00, 2004-02-12 09:00-12:00, 2004-02-13 to 2004-02-14 08:00-12:00, 13:00-17:00, 2004-02-19 09:00-12:00, 2004-02-20 to 2004-02-21 08:00-12:00, 13:00-17:00, 2004-02-26 09:00-12:00, 2004-02-27 to 2004-02-28 08:00-12:00, 13:00-17:00.

## Resources

| Resource | Rate |
| --- | --- |
| Dante Dionne |  |
| Jason Koeppe | 50 |
| Alex Alonso | 50 |

## Schedule

| ID | WBS | Task | Duration | Start | Finish | Predecessors | Complete | Baseline start | Baseline finish | Baseline duration | Constraint | Deadline | Resources | Work | Actual work | Cost | Actual cost |
| --- | --- | --- | --- | --- | --- | --- | --- | --- | --- | --- | --- | --- | --- | --- | --- | --- | --- |
| 1 | 1 | **Application Concept and Scope Definition** | 39.29d | 2003-11-14 A | 2004-01-09 A |  | 100% | 2003-11-14 | 2003-12-19 | 29.32d |  | 2003-11-22 |  | 124h | 124h | 6,200 | 6,200 |
| 2 | 1.1 | Develop concept and a draft of a scope document | 2d | 2003-11-14 A | 2003-11-14 A |  | 100% | 2003-11-14 | 2003-11-14 | 2d | start no earlier than 2003-11-14 |  | Jason Koeppe; Dante Dionne | 12h | 12h | 600 | 600 |
| 3 | 1.2 | **Mockup Creation** | 11.98d | 2003-11-27 A | 2003-12-12 A |  | 100% | 2003-11-27 | 2003-12-05 | 10.66d |  |  |  | 28h | 28h | 1,400 | 1,400 |
| 4 | 1.2.1 | **Create Mockups for Billing & Promotion Code Screens** | 9.65d | 2003-11-27 A | 2003-12-05 A |  | 100% | 2003-11-27 | 2003-12-04 | 8.66d |  |  | Jason Koeppe | 16h | 16h | 800 | 800 |
| 5 | 1.2.1.1 | Create Price Override (Modified) Mockup | 2h | 2003-11-27 A | 2003-11-28 A | 2 | 100% | 2003-11-27 | 2003-11-28 | 2h | start no earlier than 2003-11-27 |  | Jason Koeppe | 2h | 2h | 100 | 100 |
| 6 | 1.2.1.2 | Create New Customer Signup (within Admin) Mockup | 2h | 2003-11-28 A | 2003-11-28 A | 5 | 100% | 2003-11-28 | 2003-11-28 | 2h | start no earlier than 2003-11-20 |  | Jason Koeppe | 2h | 2h | 100 | 100 |
| 7 | 1.2.1.3 | Create Add Promotion Code Mockup | 2h | 2003-11-28 A | 2003-12-05 A | 6 | 100% | 2003-11-28 | 2003-12-04 | 2h | start no earlier than 2003-11-20 |  | Jason Koeppe | 2h | 2h | 100 | 100 |
| 8 | 1.2.1.4 | Create View/Edit/Remove Promotion Code Mockup | 2h | 2003-12-05 A | 2003-12-05 A | 7 | 100% | 2003-12-04 | 2003-12-04 | 2h | start no earlier than 2003-11-20 |  | Jason Koeppe | 2h | 2h | 100 | 100 |
| 9 | 1.2.2 | **Create Mockups for Users & Security Groups Screens** | 2.33d | 2003-12-05 A | 2003-12-12 A | 8 | 100% | 2003-12-04 | 2003-12-05 | 2d |  |  | Jason Koeppe | 12h | 12h | 600 | 600 |
| 10 | 1.2.2.1 | Create Add User Mockup | 2h | 2003-12-05 A | 2003-12-05 A |  | 100% | 2003-12-04 | 2003-12-04 | 2h |  |  | Jason Koeppe | 2h | 2h | 100 | 100 |
| 11 | 1.2.2.2 | Create View/Edit/Remove User Mockup | 2h | 2003-12-05 A | 2003-12-05 A | 10 | 100% | 2003-12-04 | 2003-12-04 | 2h |  |  | Jason Koeppe | 2h | 2h | 100 | 100 |
| 12 | 1.2.2.3 | Create Add Security Group Mockup | 1h | 2003-12-05 A | 2003-12-12 A | 11 | 100% | 2003-12-04 | 2003-12-04 | 1h |  |  | Jason Koeppe | 1h | 1h | 50 | 50 |
| 13 | 1.2.2.4 | Create View/Edit/Remove Security Group Mockup | 1h | 2003-12-12 A | 2003-12-12 A | 12 | 100% | 2003-12-04 | 2003-12-05 | 1h |  |  | Jason Koeppe | 1h | 1h | 50 | 50 |
| 14 | 1.3 | Mockup Approval & Sign Off (Including iterations and changes) | 8d | 2003-12-12 A | 2004-01-09 A | 13 | 100% | 2003-12-05 | 2003-12-19 | 8d |  |  | Jason Koeppe; Dante Dionne; Alex Alonso | 72h | 72h | 3,600 | 3,600 |
| 15 | 1.4 | Develop Testing Procedures for each mockup/screen | 4d | 2003-12-12 A | 2003-12-18 A | 13 | 100% | 2003-12-05 | 2003-12-12 | 4d | finish no earlier than 2003-12-12 |  | Dante Dionne | 12h | 12h | 600 | 600 |
| 16 | 2 | **Development Stage** | 64.67d? | 2004-01-09 A | 2004-02-19 A | 13 | 100% | 2003-12-19 | 2004-02-11 | 49.32d? |  |  |  | 232h | 232h | 11,600 | 11,600 |
| 17 | 2.1 | **Billing & Promotion Coding** | 23.67d | 2004-01-09 A | 2004-01-30 A | 13 | 100% | 2003-12-19 | 2004-01-16 | 16.66d |  |  |  | 36h | 36h | 1,800 | 1,800 |
| 18 | 2.1.1 | Database Design Changes (adding two tables and all necessary stored procedures) | 4d | 2004-01-09 A | 2004-01-16 A | 14 | 100% | 2003-12-19 | 2004-01-08 | 4d |  |  | Jason Koeppe | 12h | 12h | 600 | 600 |
| 19 | 2.1.2 | Code Price Override (Modified) Screen | 2d | 2004-01-16 A | 2004-01-22 A | 18 | 100% | 2004-01-08 | 2004-01-08 | 2d |  |  | Jason Koeppe | 6h | 6h | 300 | 300 |
| 20 | 2.1.3 | Code New Customer Signup (within Admin) Screen | 2d | 2004-01-22 A | 2004-01-23 A | 19 | 100% | 2004-01-08 | 2004-01-09 | 2d |  |  | Jason Koeppe | 6h | 6h | 300 | 300 |
| 21 | 2.1.4 | Code Add Promotion Code Screen | 2d | 2004-01-23 A | 2004-01-29 A | 20 | 100% | 2004-01-09 | 2004-01-15 | 2d |  |  | Jason Koeppe | 6h | 6h | 300 | 300 |
| 22 | 2.1.5 | Code View/Edit/Remove Promotion Code Screen | 2d | 2004-01-29 A | 2004-01-30 A | 21 | 100% | 2004-01-15 | 2004-01-16 | 2d |  |  | Jason Koeppe | 6h | 6h | 300 | 300 |
| 23 | 2.2 | **Users & Security Groups** | 11.67d | 2004-01-30 A | 2004-02-05 A | 22 | 100% | 2004-01-16 | 2004-01-29 | 8.67d |  |  | Jason Koeppe | 52h | 52h | 2,600 | 2,600 |
| 24 | 2.2.1 | Make database additions and modifications | 2h | 2004-01-30 A | 2004-02-02 A | 22 | 100% | 2004-01-16 | 2004-01-16 | 2h |  |  | Jason Koeppe | 2h | 2h | 100 | 100 |
| 25 | 2.2.2 | Code Add User Screen | 2d | 2004-02-02 A | 2004-02-02 A | 24 | 100% | 2004-01-16 | 2004-01-22 | 2d |  |  | Jason Koeppe | 6h | 6h | 300 | 300 |
| 26 | 2.2.3 | Code View/Edit/Remove User Screen | 2d | 2004-02-02 A | 2004-02-03 A | 25 | 100% | 2004-01-22 | 2004-01-22 | 2d |  |  | Jason Koeppe | 6h | 6h | 300 | 300 |
| 27 | 2.2.4 | Code Add Security Group Screen | 2d | 2004-02-03 A | 2004-02-04 A | 26 | 100% | 2004-01-22 | 2004-01-23 | 2d |  |  | Jason Koeppe | 6h | 6h | 300 | 300 |
| 28 | 2.2.5 | Code View/Edit/Remove Security Group Screen | 2d | 2004-02-04 A | 2004-02-05 A | 27 | 100% | 2004-01-23 | 2004-01-29 | 2d |  |  | Jason Koeppe | 6h | 6h | 300 | 300 |

| ID | WBS | Task | Duration | Start | Finish | Predecessors | Complete | Baseline start | Baseline finish | Baseline duration | Resources | Work | Actual work | Cost | Actual cost |
| --- | --- | --- | --- | --- | --- | --- | --- | --- | --- | --- | --- | --- | --- | --- | --- |
| 29 | 2.3 | **Reporting** | 29.33d? | 2004-02-05 A | 2004-02-19 A | 20 | 100% | 2004-01-29 | 2004-02-11 | 24d? | Jason Koeppe | 144h | 144h | 7,200 | 7,200 |
| 30 | 2.3.1 | Code Inventory - Upload Required List Report | 2d? | 2004-02-05 A | 2004-02-06 A | 28 | 100% | 2004-01-29 | 2004-01-30 | 2d? | Jason Koeppe | 6h | 6h | 300 | 300 |
| 31 | 2.3.2 | Code Inventory - Never Uploaded List Report | 2d? | 2004-02-06 A | 2004-02-09 A | 30 | 100% | 2004-01-30 | 2004-01-30 | 2d? | Jason Koeppe | 6h | 6h | 300 | 300 |
| 32 | 2.3.3 | Code Inventory - In Process Report | 2d? | 2004-02-09 A | 2004-02-09 A | 31 | 100% | 2004-01-30 | 2004-02-02 | 2d? | Jason Koeppe | 6h | 6h | 300 | 300 |
| 33 | 2.3.4 | Code Accounting - Total Revenue | 2d? | 2004-02-09 A | 2004-02-10 A | 32 | 100% | 2004-02-02 | 2004-02-03 | 2d? | Jason Koeppe | 6h | 6h | 300 | 300 |
| 34 | 2.3.5 | Code Accounting - TBD | 2d? | 2004-02-10 A | 2004-02-11 A | 33 | 100% | 2004-02-03 | 2004-02-04 | 2d? | Jason Koeppe | 6h | 6h | 300 | 300 |
| 35 | 2.3.6 | Code Site Usage - Logins (Daily, Weekly, Monthly) | 2d? | 2004-02-11 A | 2004-02-12 A | 34 | 100% | 2004-02-04 | 2004-02-04 | 2d? | Jason Koeppe | 6h | 6h | 300 | 300 |
| 36 | 2.3.7 | Code Site Usage - Product Search Success (Dailly, Weekly, Monthly) | 2d? | 2004-02-12 A | 2004-02-13 A | 35 | 100% | 2004-02-04 | 2004-02-05 | 2d? | Jason Koeppe | 6h | 6h | 300 | 300 |
| 37 | 2.3.8 | Code Site Usage - Product Search Failure (Dailly, Weekly, Monthly) | 2d? | 2004-02-13 A | 2004-02-16 A | 36 | 100% | 2004-02-05 | 2004-02-06 | 2d? | Jason Koeppe | 6h | 6h | 300 | 300 |
| 38 | 2.3.9 | Code Site Usage - Product Search Total (Dailly, Weekly, Monthly) | 2d? | 2004-02-16 A | 2004-02-17 A | 37 | 100% | 2004-02-06 | 2004-02-09 | 2d? | Jason Koeppe | 6h | 6h | 300 | 300 |
| 39 | 2.3.10 | Code Site Usage - RFQ's (Dailly, Weekly, Monthly) | 2d? | 2004-02-17 A | 2004-02-17 A | 38 | 100% | 2004-02-09 | 2004-02-09 | 2d? | Jason Koeppe | 6h | 6h | 300 | 300 |
| 40 | 2.3.11 | Code Site Usage - Offers Sent (Dailly, Weekly, Monthly) | 2d? | 2004-02-17 A | 2004-02-18 A | 39 | 100% | 2004-02-09 | 2004-02-10 | 2d? | Jason Koeppe | 6h | 6h | 300 | 300 |
| 41 | 2.3.12 | Code Site Usage - Requirements Sent (Dailly, Weekly, Monthly) | 2d? | 2004-02-18 A | 2004-02-19 A | 40 | 100% | 2004-02-10 | 2004-02-11 | 2d? | Jason Koeppe | 6h | 6h | 300 | 300 |
| 42 | 3 | **QA Stage Begins** | 21.33d | 2004-02-19 A | 2004-03-01 A | 20 | 100% | 2004-02-11 | 2004-02-19 | 16d |  | 96h | 96h | 4,800 | 4,800 |
| 43 | 3.1 | Execute formal testing scripts from task 3 | 6d | 2004-02-19 A | 2004-02-24 A | 41 | 100% | 2004-02-11 | 2004-02-13 | 6d | Dante Dionne; Alex Alonso | 36h | 36h | 1,800 | 1,800 |
| 44 | 3.2 | Other focus group testing (Paul or others) as needed | 10d | 2004-02-24 A | 2004-03-01 A | 43 | 100% | 2004-02-13 | 2004-02-19 | 10d | Dante Dionne; Alex Alonso | 60h | 60h | 3,000 | 3,000 |
